# Valuación 2b - redistribución

Schedule from MS Project, 2020-01-01 to 2020-03-04, 6 hours a day, costs in $.

## Calendars

- Estándar: Mon-Fri 10:00-13:00, 15:00-18:00; Sat-Sun off.

## Resources

| Resource | Unit | Rate | Cost per use |
| --- | --- | --- | --- |
| Consultor ext. |  | 250 | 1500 |
| Consultor |  | 150 |  |
| Analista |  | 50 |  |
| Asistente |  | 20 |  |
| Automovil |  | 13.33 | 10 |
| Gasolina | litro | 2 |  |
| Software | licencia | 300 |  |
| Hojas | resma | 15 |  |
| Encuadernacion | encuadernacion | 50 |  |

## Schedule

| ID | Task | Type | Duration | Start | Finish | Predecessors | Total slack | Free slack | Resources | Work | Cost |
| --- | --- | --- | --- | --- | --- | --- | --- | --- | --- | --- | --- |
| 1 | INICIO | milestone | 0d | 2020-01-01 | 2020-01-01 |  | 0d |  |  |  |  |
| 2 | BUS. INFO |  | 4d | 2020-01-01 | 2020-01-06 | 1 | 8.67d | 0d | Analista [200%]; Asistente [400%] | 144h | 4,320 |
| 3 | BUS. INVERSORES |  | 5.2w | 2020-01-01 | 2020-02-18 | 1 | 0d |  | Consultor [300%]; Automovil; Gasolina [150 litro] | 360h | 42,010 |
| 4 | ELAB. DIAGNOSTICO |  | 5d | 2020-01-07 | 2020-01-13 | 2 | 28.67d | 20d | Consultor [200%]; Analista [400%] | 180h | 15,000 |
| 5 | VALUAR EMP. |  | 1mo | 2020-01-07 | 2020-02-03 | 2 | 8.67d | 0d | Consultor ext.; Consultor [300%]; Analista [200%]; Asistente | 840h | 99,900 |
| 6 | SEL. INVERSORES |  | 240min | 2020-02-19 | 2020-02-19 | 3 | 0d |  | Consultor [200%]; Asistente | 12h | 1,280 |
| 7 | AN. SENSIBILIDAD |  | 5d | 2020-02-04 | 2020-02-10 | 5 | 8.67d | 0d | Consultor [200%]; Analista; Software [1 licencia] | 90h | 10,800 |
| 8 | ELAB. INFORMES |  | 8d | 2020-02-11 | 2020-02-20 | 4, 7 | 8.67d |  | Consultor [200%]; Analista [400%]; Hojas [10 resma]; Encuadernacion [5 encuadernacion] | 288h | 24,690 |
| 9 | NEGOCIACIÓN |  | 60h | 2020-02-19 | 2020-03-04 | 6 | 0d |  | Consultor [300%] | 180h | 27,000 |
| 10 | FIN | milestone | 0d | 2020-03-04 | 2020-03-04 | 8, 9 | 0d |  |  |  |  |
